# Blue_Zuma_Project_Part1

How a schedule from MS Project changed from version to version. A marks actual dates.

## Version 1 (saved 2008-04-23, file Blue_Zuma_Project_Part1.mpp)

| ID | WBS | Task | Duration | Start | Finish | Predecessors | Total float |
| --- | --- | --- | --- | --- | --- | --- | --- |
| 1 | 1 | **Product Development Project** | 250d | 2008-01-02 | 2008-12-22 |  | 0d |
| 2 |  | Market Analysis | 25d | 2008-01-02 | 2008-02-05 |  | 0d |
| 3 |  | Product Design | 40d | 2008-02-06 | 2008-04-01 | 2 | 0d |
| 4 |  | Manufacturing Study | 20d | 2008-02-06 | 2008-03-04 | 2 | 20d |
| 5 |  | Product Design Selection | 10d | 2008-04-02 | 2008-04-15 | 3, 4 | 0d |
| 6 |  | Detailed Marketing Plan | 15d | 2008-04-16 | 2008-05-06 | 5 | 159d |
| 7 |  | Manufacturing Process | 30d | 2008-04-16 | 2008-05-28 | 5 | 30d |
| 8 |  | Detailed Product Design | 50d | 2008-04-16 | 2008-06-25 | 5 | 0d |
| 9 |  | Test Prototype | 10d | 2008-06-26 | 2008-07-10 | 8 | 0d |
| 10 |  | Finalized Product Design | 25d | 2008-07-11 | 2008-08-14 | 7, 9 | 0d |
| 11 |  | Order Components | 7d | 2008-08-15 | 2008-08-25 | 10 | 27d |
| 12 |  | Order Production Equipment | 14d | 2008-08-15 | 2008-09-03 | 10 | 0d |
| 13 |  | Install Production Equipment | 35d | 2008-10-31 | 2008-12-19 | 11FS+20d, 12FS+40d | 0d |
| 14 |  | Celebrate | 1d | 2008-12-22 | 2008-12-22 | 6, 13 | 0d |

## Version 2 (saved 2008-05-18, file Blue_Zuma_Project_Part2.mpp)

Last finish 2008-12-22 → 2009-02-19 (+59d).

Changed:

| ID | Task | Start | Finish | Duration | Total float | Other |
| --- | --- | --- | --- | --- | --- | --- |
| 1 | **Product Development Project** |  | 2008-12-22 → 2009-02-19 (+59d) | 250d → 290d |  |  |
| 2 | Market Analysis |  |  |  |  | resources none → Marketing Specialist [400%] |
| 3 | Product Design |  |  |  | 0d → 20d | resources none → Marketing Specialist; Design Engineer [400%]; Development Engineer [200%]; Industrial Engineer; Purchasing Agent |
| 4 | Manufacturing Study | 2008-02-06 → 2008-04-02 (+56d) | 2008-03-04 → 2008-04-29 (+56d) |  | 20d → 0d | resources none → Industrial Engineer [400%]; Development Engineer [200%] |
| 5 | Product Design Selection | 2008-04-02 → 2008-04-30 (+28d) | 2008-04-15 → 2008-05-13 (+28d) |  |  | resources none → Marketing Specialist [200%]; Design Engineer [300%]; Development Engineer [200%]; Industrial Engineer [200%]; Purchasing Agent [25%] |
| 6 | Detailed Marketing Plan | 2008-04-16 → 2008-07-25 (+100d) | 2008-05-06 → 2008-08-14 (+100d) |  | 159d → 129d | resources none → Marketing Specialist [400%] |
| 7 | Manufacturing Process | 2008-04-16 → 2008-07-25 (+100d) | 2008-05-28 → 2008-09-05 (+100d) |  | 30d → 0d | resources none → Design Engineer; Development Engineer [200%]; Industrial Engineer [300%] |
| 8 | Detailed Product Design | 2008-04-16 → 2008-05-14 (+28d) | 2008-06-25 → 2008-07-24 (+29d) |  | 0d → 20d | resources none → Marketing Specialist [200%]; Design Engineer [400%]; Development Engineer [200%]; Industrial Engineer [200%]; Purchasing Agent [25%] |
| 9 | Test Prototype | 2008-06-26 → 2008-07-25 (+29d) | 2008-07-10 → 2008-08-07 (+28d) |  | 0d → 20d | resources none → Design Engineer [300%]; Development Engineer [200%] |
| 10 | Finalized Product Design | 2008-07-11 → 2008-09-08 (+59d) | 2008-08-14 → 2008-10-10 (+57d) |  |  | resources none → Marketing Specialist [200%]; Design Engineer [300%]; Development Engineer [300%]; Industrial Engineer [200%] |
| 11 | Order Components | 2008-08-15 → 2008-10-31 (+77d) | 2008-08-25 → 2008-11-10 (+77d) |  | 27d → 13d | resources none → Purchasing Agent |
| 12 | Order Production Equipment | 2008-08-15 → 2008-10-13 (+59d) | 2008-09-03 → 2008-10-30 (+57d) |  |  | resources none → Purchasing Agent |
| 13 | Install Production Equipment | 2008-10-31 → 2008-12-31 (+61d) | 2008-12-19 → 2009-02-18 (+61d) |  |  | resources none → Development Engineer [300%]; Industrial Engineer [400%]; Design Engineer |
| 14 | Celebrate | 2008-12-22 → 2009-02-19 (+59d) | 2008-12-22 → 2009-02-19 (+59d) |  |  | resources none → Development Engineer [400%]; Industrial Engineer [400%]; Design Engineer [400%]; Marketing Specialist [400%]; Purchasing Agent |

## Version 3 (saved 2008-05-24, file Blue_Zuma_Project_Part3.mpp)

Last finish 2009-02-19 → 2009-01-28 (-22d).

Changed:

| ID | Task | Start | Finish | Duration | Total float | Other |
| --- | --- | --- | --- | --- | --- | --- |
| 1 | **Product Development Project** |  | 2009-02-19 → 2009-01-28 (-22d) | 290d → 274d |  |  |
| 7 | Manufacturing Process | 2008-07-25 → 2008-07-15 (-10d) | 2008-09-05 → 2008-08-25 (-11d) |  |  | constraint none → start no earlier than 2008-07-15 |
| 8 | Detailed Product Design |  | 2008-07-24 → 2008-07-14 (-10d) | 50d → 42d |  | resources Marketing Specialist [200%]; Design Engineer [400%]; Development Engineer [200%]; Industrial Engineer [200%]; Purchasing Agent [25%] → Marketing Specialist [200%]; Design Engineer [400%]; Development Engineer [200%]; Industrial Engineer [200%]; Purchasing Agent [25%]; Development Engineer X; Design Engineer X |
| 9 | Test Prototype | 2008-07-25 → 2008-07-15 (-10d) | 2008-08-07 → 2008-07-28 (-10d) |  |  |  |
| 10 | Finalized Product Design | 2008-09-08 → 2008-08-26 (-13d) | 2008-10-10 → 2008-09-30 (-10d) |  |  |  |
| 11 | Order Components | 2008-10-31 → 2008-10-20 (-11d) | 2008-11-10 → 2008-10-28 (-13d) |  | 13d → 14d |  |
| 12 | Order Production Equipment | 2008-10-13 → 2008-10-01 (-12d) | 2008-10-30 → 2008-10-20 (-10d) |  |  |  |
| 13 | Install Production Equipment | 2008-12-31 → 2008-12-17 (-14d) | 2009-02-18 → 2009-01-27 (-22d) | 35d → 27d |  | resources Development Engineer [300%]; Industrial Engineer [400%]; Design Engineer → Development Engineer [300%]; Industrial Engineer [400%]; Design Engineer; Industrial Engineer X; Development Engineer X |
| 14 | Celebrate | 2009-02-19 → 2009-01-28 (-22d) | 2009-02-19 → 2009-01-28 (-22d) |  |  |  |

## Version 4 (data date 2008-08-15, saved 2008-06-11, file Blue Zuma Part 5.mpp)

Last finish 2009-01-28 → 2009-02-24 (+27d). Complete tasks 0 → 6.

Added:

| ID | Task | Duration | Start | Finish | Predecessors | Resources |
| --- | --- | --- | --- | --- | --- | --- |
| 8 | Detailed product design | 55d | 2008-05-14 A | 2008-07-31 A | 5 | Marketing specialist [200%]; Design engineer [400%]; Development engineer [200%]; Industrial engineer [200%]; Purchasing agent [25%]; Development engineer (extra); Design engineer (extra) |

Removed: 13 Install Production Equipment

Changed:

| ID | Task | Start | Finish | Duration | Complete | Total float | Predecessors | Other |
| --- | --- | --- | --- | --- | --- | --- | --- | --- |
| 1 | **Blue Zuma Project** | 2008-01-02 A | 2009-01-28 → 2009-02-24 (+27d) | 274d → 293d | 0% → 60% |  |  | was named Product Development Project; baseline start none → 2008-01-02; baseline finish none → 2009-01-28 |
| 2 | Market analysis | 2008-01-02 A | 2008-02-05 → 2008-02-01 A (-4d) | 25d → 23d | 0% → 100% | 20d → none |  | was named Market Analysis; resources Marketing Specialist [400%] → Marketing specialist [400%]; baseline start none → 2008-01-02; baseline finish none → 2008-02-05 |
| 3 | Product design | 2008-02-06 → 2008-02-04 A (-2d) | 2008-04-01 → 2008-03-20 A (-12d) | 40d → 34d | 0% → 100% | 40d → none |  | was named Product Design; resources Marketing Specialist; Design Engineer [400%]; Development Engineer [200%]; Industrial Engineer; Purchasing Agent → Marketing specialist; Design engineer [400%]; Development engineer [200%]; Industrial engineer; Purchasing agent; baseline start none → 2008-02-06; baseline finish none → 2008-04-01 |
| 4 | Manufacturing study | 2008-04-02 → 2008-03-21 A (-12d) | 2008-04-29 → 2008-04-22 A (-7d) | 20d → 23d | 0% → 100% | 20d → none |  | was named Manufacturing Study; resources Industrial Engineer [400%]; Development Engineer [200%] → Industrial engineer [400%]; Development engineer [200%]; baseline start none → 2008-04-02; baseline finish none → 2008-04-29 |
| 5 | Product design selection | 2008-04-30 → 2008-04-23 A (-7d) | 2008-05-13 A | 10d → 15d | 0% → 100% | 20d → none |  | was named Product Design Selection; resources Marketing Specialist [200%]; Design Engineer [300%]; Development Engineer [200%]; Industrial Engineer [200%]; Purchasing Agent [25%] → Marketing specialist [200%]; Design engineer [300%]; Development engineer [200%]; Industrial engineer [200%]; Purchasing agent [25%]; baseline start none → 2008-04-30; baseline finish none → 2008-05-13 |
| 6 | Detailed marketing plan |  |  |  |  | 113d → 132d |  | was named Detailed Marketing Plan; resources Marketing Specialist [400%] → Marketing specialist [400%]; baseline start none → 2008-07-25; baseline finish none → 2008-08-14 |
| 7 | Manufacturing process | 2008-07-15 → 2008-08-01 A (+17d) | 2008-08-25 → 2008-09-22 (+28d) | 30d → 36d | 0% → 31% |  |  | was named Manufacturing Process; resources Design Engineer; Development Engineer [200%]; Industrial Engineer [300%] → Design engineer; Development engineer [200%]; Industrial engineer [400%]; baseline start none → 2008-07-15; baseline finish none → 2008-08-25 |
| 9 | Test prototype | 2008-05-14 → 2008-08-01 A (+79d) | 2008-07-14 → 2008-08-15 A (+32d) | 42d → 11d | 0% → 100% | 20d → none | 5 → 8 | was named Detailed Product Design; resources Marketing Specialist [200%]; Design Engineer [400%]; Development Engineer [200%]; Industrial Engineer [200%]; Purchasing Agent [25%]; Development Engineer X; Design Engineer X → Design engineer [300%]; Development engineer [200%]; baseline start none → 2008-07-15; baseline finish none → 2008-07-28 |
| 10 | Finalized product design | 2008-07-15 → 2008-09-23 (+70d) | 2008-07-28 → 2008-10-27 (+91d) | 10d → 25d |  | 20d → 0d | 9 → 7, 9 | was named Test Prototype; resources Design Engineer [300%]; Development Engineer [200%] → Marketing specialist [200%]; Design engineer [300%]; Development engineer [300%]; Industrial engineer [200%]; baseline start none → 2008-08-26; baseline finish none → 2008-09-30 |
| 11 | Order components | 2008-08-26 → 2008-10-28 (+63d) | 2008-09-30 → 2008-11-05 (+36d) | 25d → 7d |  | 0d → 27d | 7, 10 → 10 | was named Finalized Product Design; constraint none → start no earlier than 2008-10-21; resources Marketing Specialist [200%]; Design Engineer [300%]; Development Engineer [300%]; Industrial Engineer [200%] → Purchasing agent; baseline start none → 2008-10-21; baseline finish none → 2008-10-29 |
| 12 | Order production equipment | 2008-10-20 → 2008-10-28 (+8d) | 2008-10-28 → 2008-11-14 (+17d) | 7d → 14d |  | 14d → 0d | 11 → 10 | was named Order Components; resources Purchasing Agent → Purchasing agent; baseline start none → 2008-10-01; baseline finish none → 2008-10-20 |
| 13 | Install production equipment | 2008-10-01 → 2009-01-16 (+107d) | 2008-10-20 → 2009-02-23 (+126d) | 14d → 27d |  |  | 11 → 11FS+20d, 12FS+40d | was named Order Production Equipment; resources Purchasing Agent → Development engineer [300%]; Industrial engineer [400%]; Design engineer; Industiral engineer (extra); Development engineer (extra); baseline start none → 2008-12-17; baseline finish none → 2009-01-27 |
| 14 | Celebrate | 2009-01-28 → 2009-02-24 (+27d) | 2009-01-28 → 2009-02-24 (+27d) |  |  |  | 6, Install Production Equipment → 6, 13 | resources Development Engineer [400%]; Industrial Engineer [400%]; Design Engineer [400%]; Marketing Specialist [400%]; Purchasing Agent → Development engineer [400%]; Industrial engineer [400%]; Design engineer [400%]; Marketing specialist [400%]; Purchasing agent; baseline start none → 2009-01-28; baseline finish none → 2009-01-28 |
